# CRONOGRAMA Servicio de vegetacion y plantacion OHLA

Schedule from MS Project, 2023-05-01 to 2024-04-30.
HP

## Calendars

- calendario vegetacion: Mon-Sat 08:00-13:00, 14:00-17:00; Sun off. Exceptions (off unless hours are given): 2023-05-01 (dia del trabajo), 2023-07-28 to 2023-07-29 (fiestas patrias), 2023-08-30 (santa rosa de lima), 2023-10-08 (combate de angamos), 2023-11-01 (todos los santos), 2023-12-25 (navidad).

## Schedule

| ID | WBS | Task | Type | Duration | Start | Finish | Predecessors | Total slack |
| --- | --- | --- | --- | --- | --- | --- | --- | --- |
| 1 | 1 | **CRONOGRAMA DE EJECUCION SERVICIO DE VEGETACIÓN Y PLANTACIÓN RÍO LACRAMARCA - OHLA** |  | 308d | 2023-05-01 | 2024-04-30 |  | 0d |
| 2 | 1.1 | Inicio | milestone | 0d | 2023-05-01 | 2023-05-01 |  | 308d |
| 3 | 1.2 | **TRABAJOS PRELIMINARES** |  | 29d | 2023-05-02 | 2023-06-03 |  | 0d |
| 4 | 1.2.1 | Montaje de vivero temporal, oficinas administrativas, almacén, sanitarios, etc. |  | 15d | 2023-05-02 | 2023-05-18 |  | 0d |
| 5 | 1.2.2 | Implementación de sistema de riego temporal |  | 7d | 2023-05-19 | 2023-05-26 | 4 | 286d |
| 6 | 1.2.3 | Recolección de especies para propagación |  | 7d | 2023-05-19 | 2023-05-26 | 4 | 0d |
| 7 | 1.2.4 | Preparación de bandejas para inicio de germinación y repique |  | 7d | 2023-05-27 | 2023-06-03 | 6 | 279d |
| 8 | 1.2.5 | Suministro de insumos agrícolas para vivero |  | 5d | 2023-05-27 | 2023-06-01 | 6 | 0d |
| 9 | 1.3 | **SUMINISTRO DE VEGETACIÓN** |  | 175d | 2023-06-02 | 2023-12-28 |  | 0d |
| 10 | 1.3.1 | **ADQUISICIÓN DE PLANTONES (Germinación y repique)** |  | 45d | 2023-06-02 | 2023-07-24 |  | 0d |
| 11 | 1.3.1.1 | Germinación y repique |  | 45d | 2023-06-02 | 2023-07-24 | 8 | 236d |
| 12 | 1.3.1.2 | Monitoreo de especies en germinación y enraizamiento |  | 45d | 2023-06-02 | 2023-07-24 | 8 | 236d |
| 13 | 1.3.1.3 | Riego por nebulización para bandejas de germinación y enraizamiento |  | 45d | 2023-06-02 | 2023-07-24 | 8 | 0d |
| 14 | 1.3.2 | **ADQUISICIÓN DE PLANTONES (Crecimiento inicial)** |  | 70d | 2023-07-25 | 2023-10-17 |  | 0d |
| 15 | 1.3.2.1 | Monitoreo de especies durante crecimiento inicial de especies |  | 70d | 2023-07-25 | 2023-10-17 | 13 | 166d |
| 16 | 1.3.2.2 | Riego por microaspersión para crecimiento inicial de especies |  | 70d | 2023-07-25 | 2023-10-17 | 13 | 0d |
| 17 | 1.3.3 | **ADQUISICIÓN DE PLANTONES (Proceso de rustificación)** |  | 30d | 2023-10-18 | 2023-11-22 |  | 0d |
| 18 | 1.3.3.1 | Monitoreo de especies durante proceso de rustificación de especies |  | 30d | 2023-10-18 | 2023-11-22 | 16 | 136d |
| 19 | 1.3.3.2 | Riego por goteo para proceso de rustificación de especies |  | 30d | 2023-10-18 | 2023-11-22 | 16 | 0d |
| 20 | 1.3.4 | **ADQUISICIÓN DE PLANTONES (Dimensiones finales)** |  | 30d | 2023-11-23 | 2023-12-28 |  | 0d |
| 21 | 1.3.4.1 | Monitoreo de plantones en dimensiones finales |  | 30d | 2023-11-23 | 2023-12-28 | 19 | 106d |
| 22 | 1.3.4.2 | Riego por goteo para especies en dimensiones finales |  | 30d | 2023-11-23 | 2023-12-28 | 19 | 0d |
| 23 | 1.4 | **PLANTACIÓN DE ESPECIES EN SITIO DEFINITIVO** |  | 60d | 2023-12-29 | 2024-03-07 |  | 0d |
| 24 | 1.4.1 | **TRABAJOS PRELIMINARES** |  | 60d | 2023-12-29 | 2024-03-07 |  | 46d |
| 25 | 1.4.1.1 | Suministro de insumos agrícolas para plantación en sitio definitivo |  | 60d | 2023-12-29 | 2024-03-07 | 22 | 46d |
| 26 | 1.4.1.2 | Traslado de plantones a sitio definitivo |  | 60d | 2023-12-29 | 2024-03-07 | 22 | 46d |

| ID | WBS | Task | Duration | Start | Finish | Predecessors | Total slack |
| --- | --- | --- | --- | --- | --- | --- | --- |
| 27 | 1.4.2 | **SUB PROYECTO A1 HUMEDAL VILLA MARÍA MARGEN DERECHO** | 60d | 2023-12-29 | 2024-03-07 |  | 46d |
| 28 | 1.4.2.1 | Mejoramiento de suelo con tierra vegetal | 30d | 2023-12-29 | 2024-02-01 | 22 | 76d |
| 29 | 1.4.2.2 | Suministro y distribución de insumos agrícolas para plantado | 30d | 2023-12-29 | 2024-02-01 | 22 | 76d |
| 30 | 1.4.2.3 | Ubicación y delimitación de zona de plantación | 30d | 2023-12-29 | 2024-02-01 | 22 | 76d |
| 31 | 1.4.2.4 | Despedregado de terreno con medios manuales | 30d | 2023-12-29 | 2024-02-01 | 22 | 76d |
| 32 | 1.4.2.5 | Rastrillado del terreno | 30d | 2023-12-29 | 2024-02-01 | 22 | 76d |
| 33 | 1.4.2.6 | Trazado, marcación y estacado | 30d | 2023-12-29 | 2024-02-01 | 22 | 76d |
| 34 | 1.4.2.7 | Retiro y eliminación de residuos sólidos | 30d | 2023-12-29 | 2024-02-01 | 22 | 76d |
| 35 | 1.4.2.8 | Plantación de especies | 60d | 2023-12-29 | 2024-03-07 | 22 | 46d |
| 36 | 1.4.3 | **SUB PROYECTO A1 HUMEDAL VILLA MARÍA MARGEN IZQUIERDO** | 60d | 2023-12-29 | 2024-03-07 |  | 0d |
| 37 | 1.4.3.1 | Mejoramiento de suelo con tierra vegetal | 30d | 2023-12-29 | 2024-02-01 | 22 | 76d |
| 38 | 1.4.3.2 | Suministro y distribución de insumos agrícolas para plantado | 30d | 2023-12-29 | 2024-02-01 | 22 | 76d |
| 39 | 1.4.3.3 | Ubicación y delimitación de zona de plantación | 30d | 2023-12-29 | 2024-02-01 | 22 | 76d |
| 40 | 1.4.3.4 | Despedregado de terreno con medios manuales | 30d | 2023-12-29 | 2024-02-01 | 22 | 76d |
| 41 | 1.4.3.5 | Rastrillado del terreno | 30d | 2023-12-29 | 2024-02-01 | 22 | 76d |
| 42 | 1.4.3.6 | Trazado, marcación y estacado | 30d | 2023-12-29 | 2024-02-01 | 22 | 76d |
| 43 | 1.4.3.7 | Retiro y eliminación de residuos sólidos | 30d | 2023-12-29 | 2024-02-01 | 22 | 0d |
| 44 | 1.4.3.8 | Plantación de especies | 60d | 2023-12-29 | 2024-03-07 | 22 | 0d |
| 45 | 1.4.4 | **SUB PROYECTO A2 INTERVENCIÓN AVENIDA PERU** | 30d | 2024-02-02 | 2024-03-07 |  | 46d |
| 46 | 1.4.4.1 | Mejoramiento de suelo con tierra vegetal | 30d | 2024-02-02 | 2024-03-07 | 43 | 46d |
| 47 | 1.4.4.2 | Suministro y distribución de insumos agrícolas para plantado | 30d | 2024-02-02 | 2024-03-07 | 43 | 46d |
| 48 | 1.4.4.3 | Ubicación y delimitación de zona de plantación | 30d | 2024-02-02 | 2024-03-07 | 43 | 46d |
| 49 | 1.4.4.4 | Despedregado de terreno con medios manuales | 30d | 2024-02-02 | 2024-03-07 | 43 | 46d |
| 50 | 1.4.4.5 | Rastrillado del terreno | 30d | 2024-02-02 | 2024-03-07 | 43 | 46d |
| 51 | 1.4.4.6 | Trazado, marcación y estacado | 30d | 2024-02-02 | 2024-03-07 | 43 | 46d |
| 52 | 1.4.4.7 | Retiro y eliminación de residuos sólidos | 30d | 2024-02-02 | 2024-03-07 | 43 | 46d |
| 53 | 1.4.4.8 | Plantación de especies | 30d | 2024-02-02 | 2024-03-07 | 43 | 46d |

| ID | WBS | Task | Duration | Start | Finish | Predecessors | Total slack |
| --- | --- | --- | --- | --- | --- | --- | --- |
| 54 | 1.4.5 | **SUB PROYECTO A2 PAMPA DURA** | 30d | 2024-02-02 | 2024-03-07 |  | 46d |
| 55 | 1.4.5.1 | Mejoramiento de suelo con tierra vegetal | 30d | 2024-02-02 | 2024-03-07 | 43 | 46d |
| 56 | 1.4.5.2 | Suministro y distribución de insumos agrícolas para plantado | 30d | 2024-02-02 | 2024-03-07 | 43 | 46d |
| 57 | 1.4.5.3 | Ubicación y delimitación de zona de plantación | 30d | 2024-02-02 | 2024-03-07 | 43 | 46d |
| 58 | 1.4.5.4 | Despedregado de terreno con medios manuales | 30d | 2024-02-02 | 2024-03-07 | 43 | 46d |
| 59 | 1.4.5.5 | Rastrillado del terreno | 30d | 2024-02-02 | 2024-03-07 | 43 | 46d |
| 60 | 1.4.5.6 | Trazado, marcación y estacado | 30d | 2024-02-02 | 2024-03-07 | 43 | 46d |
| 61 | 1.4.5.7 | Retiro y eliminación de residuos sólidos | 30d | 2024-02-02 | 2024-03-07 | 43 | 46d |
| 62 | 1.4.5.8 | Plantación de especies | 30d | 2024-02-02 | 2024-03-07 | 43 | 46d |
| 63 | 1.4.6 | **SUB PROYECTO A2 TANGAY** | 30d | 2024-02-02 | 2024-03-07 |  | 46d |
| 64 | 1.4.6.1 | Mejoramiento de suelo con tierra vegetal | 30d | 2024-02-02 | 2024-03-07 | 43 | 46d |
| 65 | 1.4.6.2 | Suministro y distribución de insumos agrícolas para plantado | 30d | 2024-02-02 | 2024-03-07 | 43 | 46d |
| 66 | 1.4.6.3 | Ubicación y delimitación de zona de plantación | 30d | 2024-02-02 | 2024-03-07 | 43 | 46d |
| 67 | 1.4.6.4 | Despedregado de terreno con medios manuales | 30d | 2024-02-02 | 2024-03-07 | 43 | 46d |
| 68 | 1.4.6.5 | Rastrillado del terreno | 30d | 2024-02-02 | 2024-03-07 | 43 | 46d |
| 69 | 1.4.6.6 | Trazado, marcación y estacado | 30d | 2024-02-02 | 2024-03-07 | 43 | 46d |
| 70 | 1.4.6.7 | Retiro y eliminación de residuos sólidos | 30d | 2024-02-02 | 2024-03-07 | 43 | 46d |
| 71 | 1.4.6.8 | Plantación de especies | 30d | 2024-02-02 | 2024-03-07 | 43 | 46d |
| 72 | 1.4.7 | **SUB PROYECTO A3 PUENTE CHACHAPOYAS** | 30d | 2024-02-02 | 2024-03-07 |  | 46d |
| 73 | 1.4.7.1 | Mejoramiento de suelo con tierra vegetal | 30d | 2024-02-02 | 2024-03-07 | 43 | 46d |
| 74 | 1.4.7.2 | Suministro y distribución de insumos agrícolas para plantado | 30d | 2024-02-02 | 2024-03-07 | 43 | 46d |
| 75 | 1.4.7.3 | Ubicación y delimitación de zona de plantación | 30d | 2024-02-02 | 2024-03-07 | 43 | 46d |
| 76 | 1.4.7.4 | Despedregado de terreno con medios manuales | 30d | 2024-02-02 | 2024-03-07 | 43 | 46d |
| 77 | 1.4.7.5 | Rastrillado del terreno | 30d | 2024-02-02 | 2024-03-07 | 43 | 46d |
| 78 | 1.4.7.6 | Trazado, marcación y estacado | 30d | 2024-02-02 | 2024-03-07 | 43 | 46d |
| 79 | 1.4.7.7 | Retiro y eliminación de residuos sólidos | 30d | 2024-02-02 | 2024-03-07 | 43 | 46d |
| 80 | 1.4.7.8 | Plantación de especies | 30d | 2024-02-02 | 2024-03-07 | 43 | 46d |

| ID | WBS | Task | Type | Duration | Start | Finish | Predecessors | Total slack |
| --- | --- | --- | --- | --- | --- | --- | --- | --- |
| 81 | 1.5 | **ACONDICIONAMIENTO DE ESPECIES (Riego+Mantenimiento)** |  | 106d | 2023-12-29 | 2024-04-30 |  | 0d |
| 82 | 1.5.1 | Riego con camión cisterna adaptada con pitón contra incendios |  | 106d | 2023-12-29 | 2024-04-30 | 44SS | 0d |
| 83 | 1.5.2 | Mantenimiento preventivo para establecimiento de especies |  | 90d | 2024-01-17 | 2024-04-30 | 43FS-14d | 0d |
| 84 | 1.6 | Fin | milestone | 0d | 2024-04-30 | 2024-04-30 | 83 | 0d |
